# SUBCONTRATACIÓN DEL SUBPROYECTO A4 - RÍO LACRAMARCA

Schedule from Primavera P6, 2022-12-01 to 2023-04-28, data date 2022-12-01.

## Calendars

- OHLA: Mon-Sun 07:00-12:00, 13:00-18:00.

## Resources

| Resource | Group | Notes |
| --- | --- | --- |
| HH MAHRTUNEL | labor | ? |
| ROCA | material |  |

## Schedule

| ID | WBS | Activity | Type | Duration | Start | Finish | Predecessors | Total float | Free float |
| --- | --- | --- | --- | --- | --- | --- | --- | --- | --- |
|  | 1 | **HITOS DEL PROYECTO** |  |  | 2022-12-01 | 2023-04-28 |  |  |  |
| HP.010 |  | INICIO DE DE OBRA - ACCESO AL SITIO (Después de la firma del Acta de Entrega de Terreno) | milestone | 0d | 2022-12-01 | 2022-12-01 |  | 0d |  |
| HP.020 |  | INICIO DE EXCAVACIÓN | milestone | 0d | 2023-01-17 | 2023-01-17 | PLR-01-020 SS | 102d |  |
| HP.030 |  | INICIO DE RELLENO DE DIQUE | milestone | 0d | 2023-01-22 | 2023-01-22 | D.04.030 SS | 97d |  |
| HP.040 |  | CULMINACIÓN DE OBRAS | milestone | 0d | 2023-04-28 | 2023-04-28 | PCO.050, D.05.110, PCO.040, TP.050, OP.030, PCO.90 | 0d |  |
|  | 2 | **TRABAJOS PRELIMINARES** |  |  | 2022-12-01 | 2023-04-27 |  |  |  |
| TP.010 |  | MOVILIZACIÓN DE RECURSOS (PERSONAL, EQUIPOS, MATERIALES) |  | 17d | 2022-12-01 | 2022-12-17 | HP.010 | 0d |  |
| TP.050 |  | TOPOGRAFIA Y GEOREFRENCIACIÓN |  | 131d | 2022-12-18 | 2023-04-27 | TP.010 | 1d |  |
|  | 3 | **OBRAS PRELIMINARES** |  |  | 2022-12-18 | 2023-04-27 |  |  |  |
| OP.030 |  | MANTENIMIENTO DE TRANSITO Y SEGURIDAD VIAL |  | 131d | 2022-12-18 | 2023-04-27 | TP.010 | 1d |  |
| OP.010 |  | INSTALACIONES PROVISIONALES PARA LA OBRA |  | 7d | 2023-01-18 | 2023-01-24 | MV.040 SS+5d | 94d | 0d |
| OP.020 |  | CARTEL DE IDENTIFICACIÓN DE OBRA 4.8 m x 3.60 m |  | 1d | 2023-01-20 | 2023-01-20 | OP.010 SS+2d | 98d |  |
|  | C | **CONSTRUCCIÓN** |  |  | 2022-12-18 | 2023-04-28 |  |  |  |
|  | 70.1 | **SUBPROYECTO A4 RIO LACRAMARCA** |  |  | 2022-12-18 | 2023-04-28 |  |  |  |
|  | 02 | **CARRETERAS, CAMINOS, PAVIMENTOS** |  |  | 2022-12-18 | 2023-01-20 |  |  |  |
|  | 01 | **MEJORAMIENTO DE VIAS EXISTENTES** |  |  | 2022-12-18 | 2023-01-20 |  |  |  |
|  | 01 | **MOVIMIENTO DE TIERRAS** |  |  | 2022-12-18 | 2023-01-16 |  |  |  |
| MV.200 |  | ROCE Y LIMPIEZA DE MALEZA |  | 10d | 2022-12-18 | 2022-12-27 | TP.010 | 0d |  |
| MV.210 |  | MEJORAMIENTO DE VIAS EXISTENTES - SUBPROYECTO 4A A CAMBIO DE PUENTE |  | 16d | 2022-12-22 | 2023-01-06 | MV.200 SS+4d | 0d |  |
| MV.220 |  | MEJORAMIENTO DE VIAS EXISTENTES - FUENTE DE AGUA F-08 |  | 3d | 2023-01-07 | 2023-01-09 | MV.210 | 102d | 0d |
| MV.230 |  | MEJORAMIENTO DE VIAS EXISTENTES - TALLER DE MANTENIMIENTO |  | 7d | 2023-01-10 | 2023-01-16 | MV.220 | 102d |  |
|  | 02 | **REPOSICIÓN DE ESTRUCTURAS** |  |  | 2023-01-07 | 2023-01-20 |  |  |  |
| RE.200 |  | DEMOLICIÓN DE ESTRUCTURAS EXISTENTES |  | 2d | 2023-01-07 | 2023-01-08 | MV.210 | 0d |  |
| RE.210 |  | REPOSICIÓN DE PASE DE AGUA TUBERÍA HDPE CORRUGADA Ø=36" |  | 3d | 2023-01-09 | 2023-01-11 | RE.230 SS | 98d | 0d |
| RE.230 |  | REPOSICIÓN DE PASE DE AGUA TUBERÍA HDPE CORRUGADA Ø=24" |  | 3d | 2023-01-09 | 2023-01-11 | RE.200 | 98d | 0d |
| RE.250 |  | MONTAJE DE PANELES DE C°A° 2.20mx1.0mx0.20m EN PASE DE AGUA |  | 4d | 2023-01-09 | 2023-01-12 | RE.200 | 0d |  |
| RE.220 |  | ESTRUCTURA DE CONCRETO 175 Kg/cm2 DE CABEZAL ENTRADA Y SALIDA DE TUB. HDPE CORRUGADA Ø=36" |  | 9d | 2023-01-12 | 2023-01-20 | RE.210, RE.240 SS | 98d |  |
| RE.240 |  | ESTRUCTURA DE CONCRETO 175 Kg/cm2 DE CABEZAL ENTRADA Y SALIDA DE TUB. HDPE CORRUGADA Ø=24" |  | 9d | 2023-01-12 | 2023-01-20 | RE.230 | 98d | 0d |

| ID | WBS | Activity | Duration | Start | Finish | Predecessors | Total float | Free float | Resources |
| --- | --- | --- | --- | --- | --- | --- | --- | --- | --- |
|  | 00 | **GENERAL** |  | 2023-01-07 | 2023-04-28 |  |  |  |  |
|  | 2 | **PROGRAMA DE CIERRE DE OBRA** |  | 2023-01-07 | 2023-04-28 |  |  |  |  |
| PCO.50 |  | RETIRO Y ALMACENAMIENTO DE TOPSOIL DEL DME | 4d | 2023-01-07 | 2023-01-10 | MV.210 | 49d | 5d |  |
| PCO.60 |  | ACONDICIONAMIENTO DE MATERIAL EN BOTADERO | 59d | 2023-01-16 | 2023-03-15 | PCO.50, DC.040 SS | 44d |  |  |
| PCO.70 |  | COLOCACIÓN DE CAPA SUPERFICIAL DEL DME | 5d | 2023-03-18 | 2023-03-22 | R.010 | 37d |  |  |
| PCO.90 |  | RESTAURACIÓN DE ÁREAS DE INSTALACIONES PROVISIONALES | 4d | 2023-04-25 | 2023-04-28 | D.A4.D1.100, D.A4.DI.110 | 0d |  |  |
|  | 14 | **REFUERZO DE RIBERA DEL RIO** |  | 2023-01-13 | 2023-04-24 |  |  |  |  |
|  | 6 | **DESCOLMATACIÓN DE CAUCE** |  | 2023-01-13 | 2023-02-22 |  |  |  |  |
| DC.010 |  | DESCOLMATACIÓN DE CAUCE NATURAL EN RIO LACRAMARCA | 24d | 2023-01-13 | 2023-02-05 | RE.250 | 0d |  |  |
| DC.040 |  | DESBROCE Y LIMPIEZA EN ZONA NO BOSCOSA SUBPROYECTO A4 | 38d | 2023-01-16 | 2023-02-22 | DC.010 SS+3d | 0d |  |  |
| DC.020 |  | DESCOLMATACIÓN DE CAUCE NATURAL EN BRAZO SECUNDARIO | 6d | 2023-02-06 | 2023-02-11 | DC.010 | 73d | 0d |  |
| DC.030 |  | DESCOLMATACIÓN DE CAUCE NATURAL EN QUEBRADA PAMPA DEL TORO | 3d | 2023-02-12 | 2023-02-14 | DC.020 | 73d |  |  |
|  | 5 | **DIQUES DE TIERRA COMPACTADA CON ENROCADO** |  | 2023-01-21 | 2023-04-24 |  |  |  |  |
|  | 9 | **DIQUE DE TIERRA COMPACTADA A4-D-01-BRAZO PRINCIPAL** |  | 2023-01-21 | 2023-04-24 |  |  |  |  |
| D.A4.D1.010 |  | EXCAVACIÓN EN TERRENO NATURAL CON EQUIPO | 32d | 2023-01-21 | 2023-02-21 | DC.040 SS+5d | 0d |  |  |
| D.A4.D1.015 |  | TRANSPORTE DE MATERIAL EXCEDENTE | 32d | 2023-01-21 | 2023-02-21 | D.A4.D1.010 SS | 66d |  |  |
| D.A4.D1.020 |  | PREPARACIÓN DE FUNDACIÓN DE CUERPO DE DIQUE | 2d | 2023-01-31 | 2023-02-01 | D.A4.D1.010 SS+10d | 0d |  |  |
| D.A4.D1.030 |  | CONFORMACION DE CUERPO DE DIQUE | 2d | 2023-02-02 | 2023-02-03 | D.A4.D1.020 | 0d |  |  |
| D.A4.D1.040 |  | EXCAVACIÓN EN UÑA CON EQUIPO | 20d | 2023-02-04 | 2023-02-23 | D.A4.D1.030 | 0d |  |  |
| D.A4.D1.050 |  | PERFILADO Y COMPACTACIÓN EN ZONA DE CORTE | 20d | 2023-02-05 | 2023-02-24 | D.A4.D1.040 SS+1d | 0d |  | HH MAHRTUNEL [40.1 h] |
| D.A4.D1.060 |  | COLOCACIÓN DE GEOTEXTIL NO TEJIDO 400 gr/m2 | 20d | 2023-02-10 | 2023-03-01 | D.A4.D1.050 SS+5d | 0d |  | HH MAHRTUNEL [67 h] |
| D.A4.D1.070 |  | TRANSPORTE DE ROCA | 66d | 2023-02-10 | 2023-04-16 | D.A4.D1.060 SS | 0d |  | ROCA [205] |
| D.A4.D1.080 |  | COLOCACIÓN Y ACOMODO DE ROCA EN UÑA DEL DIQUE | 50d | 2023-02-11 | 2023-04-01 | D.A4.D1.070 SS+1d | 0d |  |  |
| D.A4.D1.090 |  | COLOCACIÓN Y ACOMODO DE ROCA EN TALUD DEL DIQUE | 58d | 2023-02-16 | 2023-04-14 | D.A4.D1.080 SS+5d | 0d |  |  |
| D.A4.D1.100 |  | CONFORMACIÓN DE MATERIAL GRANULAR EN CORONA DE DIQUE (e=0.30 m) | 10d | 2023-04-15 | 2023-04-24 | D.A4.D1.090 | 0d |  | HH MAHRTUNEL [285.7 h] |

| ID | WBS | Activity | Duration | Start | Finish | Predecessors | Total float | Free float | Resources |
| --- | --- | --- | --- | --- | --- | --- | --- | --- | --- |
|  | 1 | **DIQUE DE TIERRA COMPACTADA A4-I-01-BRAZO PRINCIPAL** |  | 2023-01-21 | 2023-03-23 |  |  |  |  |
| D.A4.I1.010 |  | EXCAVACIÓN EN TERRENO NATURAL CON EQUIPO | 22d | 2023-01-21 | 2023-02-11 | DC.040 SS+5d | 0d |  |  |
| D.A4.I1.020 |  | TRANSPORTE DE MATERIAL EXCEDENTE | 22d | 2023-01-21 | 2023-02-11 | D.A4.I1.010 SS | 76d |  |  |
| D.A4.I1.030 |  | PREPARACIÓN DE FUNDACIÓN DE CUERPO DE DIQUE | 2d | 2023-02-02 | 2023-02-03 | D.A4.I1.010 SS+12d | 13d | 0d |  |
| D.A4.I1.040 |  | CONFORMACION DE CUERPO DE DIQUE | 2d | 2023-02-04 | 2023-02-05 | D.A4.I1.030 | 13d | 0d |  |
| D.A4.I1.050 |  | EXCAVACIÓN EN UÑA CON EQUIPO | 10d | 2023-02-06 | 2023-02-15 | D.A4.I1.040 | 13d | 0d |  |
| D.A4.I1.060 |  | PERFILADO Y COMPACTACIÓN EN ZONA DE CORTE | 10d | 2023-02-09 | 2023-02-18 | D.A4.I1.050 SS+3d | 13d | 0d | HH MAHRTUNEL [40.1 h] |
| D.A4.I1.070 |  | COLOCACIÓN DE GEOTEXTIL NO TEJIDO 400 gr/m2 | 10d | 2023-02-14 | 2023-02-23 | D.A4.I1.060 SS+5d | 13d | 0d | HH MAHRTUNEL [67 h] |
| D.A4.I1.080 |  | TRANSPORTE DE ROCA | 31d | 2023-02-14 | 2023-03-16 | D.A4.I1.070 SS | 13d | 0d | ROCA [205] |
| D.A4.I1.090 |  | COLOCACIÓN Y ACOMODO DE ROCA EN UÑA DEL DIQUE | 25d | 2023-02-15 | 2023-03-11 | D.A4.I1.080 SS+1d | 13d | 0d |  |
| D.A4.I1.100 |  | COLOCACIÓN Y ACOMODO DE ROCA EN TALUD DEL DIQUE | 26d | 2023-02-20 | 2023-03-17 | D.A4.I1.090 SS+5d | 36d | 0d |  |
| D.A4.I1.110 |  | CONFORMACIÓN DE MATERIAL GRANULAR EN CORONA DE DIQUE (e=0.30 m) | 6d | 2023-03-18 | 2023-03-23 | D.A4.I1.100 | 36d |  | HH MAHRTUNEL [285.7 h] |
|  | 3 | **DIQUE DE TIERRA COMPACTADA A4-D-00-PAMPA DE TORO** |  | 2023-03-12 | 2023-03-31 |  |  |  |  |
| D.A4.DP.010 |  | EXCAVACIÓN EN TERRENO NATURAL CON EQUIPO | 2d | 2023-03-12 | 2023-03-13 | D.A4.I1.090 | 13d | 0d |  |
| D.A4.DP.020 |  | TRANSPORTE DE MATERIAL EXCEDENTE | 2d | 2023-03-12 | 2023-03-13 | D.A4.DP.010 SS | 46d |  |  |
| D.A4.DP.030 |  | PREPARACIÓN DE FUNDACIÓN DE CUERPO DE DIQUE | 1d | 2023-03-14 | 2023-03-14 | D.A4.DP.010 | 13d | 0d |  |
| D.A4.DP.040 |  | CONFORMACION DE CUERPO DE DIQUE | 1d | 2023-03-15 | 2023-03-15 | D.A4.DP.030 | 13d | 0d |  |
| D.A4.DP.050 |  | EXCAVACIÓN EN UÑA CON EQUIPO | 2d | 2023-03-16 | 2023-03-17 | D.A4.DP.040 | 13d | 0d |  |
| D.A4.DP.060 |  | PERFILADO Y COMPACTACIÓN EN ZONA DE CORTE | 2d | 2023-03-17 | 2023-03-18 | D.A4.DP.050 SS+1d | 13d | 0d | HH MAHRTUNEL [40.1 h] |
| D.A4.DP.070 |  | COLOCACIÓN DE GEOTEXTIL NO TEJIDO 400 gr/m2 | 2d | 2023-03-19 | 2023-03-20 | D.A4.DP.060 | 13d | 0d | HH MAHRTUNEL [67 h] |
| D.A4.DP.080 |  | TRANSPORTE DE ROCA | 11d | 2023-03-19 | 2023-03-29 | D.A4.DP.070 SS | 13d | 0d | ROCA [205] |
| D.A4.DP.090 |  | COLOCACIÓN Y ACOMODO DE ROCA EN UÑA DEL DIQUE | 6d | 2023-03-20 | 2023-03-25 | D.A4.DP.080 SS+1d | 13d | 0d |  |
| D.A4.DP.100 |  | COLOCACIÓN Y ACOMODO DE ROCA EN TALUD DEL DIQUE | 8d | 2023-03-23 | 2023-03-30 | D.A4.DP.090 SS+3d | 13d | 0d |  |
| D.A4.DP.110 |  | CONFORMACIÓN DE MATERIAL GRANULAR EN CORONA DE DIQUE (e=0.30 m) | 1d | 2023-03-31 | 2023-03-31 | D.A4.DP.100 | 28d |  | HH MAHRTUNEL [285.7 h] |

| ID | WBS | Activity | Duration | Start | Finish | Predecessors | Total float | Free float | Resources |
| --- | --- | --- | --- | --- | --- | --- | --- | --- | --- |
|  | 2 | **DIQUE DE TIERRA COMPACTADA A4-I-00-PAMPA DE TORO** |  | 2023-03-20 | 2023-04-15 |  |  |  |  |
| D.A4.IP.010 |  | EXCAVACIÓN EN TERRENO NATURAL CON EQUIPO | 2d | 2023-03-20 | 2023-03-21 | D.A4.DP.050 FS+2d | 13d | 0d |  |
| D.A4.IP.020 |  | TRANSPORTE DE MATERIAL EXCEDENTE | 2d | 2023-03-20 | 2023-03-21 | D.A4.IP.010 SS | 38d |  |  |
| D.A4.IP.030 |  | PREPARACIÓN DE FUNDACIÓN DE CUERPO DE DIQUE | 2d | 2023-03-22 | 2023-03-23 | D.A4.IP.010 | 13d | 0d |  |
| D.A4.IP.040 |  | CONFORMACION DE CUERPO DE DIQUE | 2d | 2023-03-23 | 2023-03-24 | D.A4.IP.030 SS+1d | 13d | 0d |  |
| D.A4.IP.050 |  | EXCAVACIÓN EN UÑA CON EQUIPO | 2d | 2023-03-25 | 2023-03-26 | D.A4.IP.040 | 13d | 0d |  |
| D.A4.IP.060 |  | PERFILADO Y COMPACTACIÓN EN ZONA DE CORTE | 2d | 2023-03-27 | 2023-03-28 | D.A4.IP.050 | 13d | 0d | HH MAHRTUNEL [40.1 h] |
| D.A4.IP.070 |  | COLOCACIÓN DE GEOTEXTIL NO TEJIDO 400 gr/m2 | 2d | 2023-03-29 | 2023-03-30 | D.A4.IP.060 | 13d | 0d | HH MAHRTUNEL [67 h] |
| D.A4.IP.080 |  | TRANSPORTE DE ROCA | 15d | 2023-03-29 | 2023-04-12 | D.A4.IP.070 SS | 13d | 0d | ROCA [205] |
| D.A4.IP.090 |  | COLOCACIÓN Y ACOMODO DE ROCA EN UÑA DEL DIQUE | 6d | 2023-03-31 | 2023-04-05 | D.A4.IP.080 SS+2d, D.A4.DP.100 | 13d | 0d |  |
| D.A4.IP.100 |  | COLOCACIÓN Y ACOMODO DE ROCA EN TALUD DEL DIQUE | 9d | 2023-04-06 | 2023-04-14 | D.A4.IP.090 | 13d | 0d |  |
| D.A4.IP.110 |  | CONFORMACIÓN DE MATERIAL GRANULAR EN CORONA DE DIQUE (e=0.30 m) | 1d | 2023-04-15 | 2023-04-15 | D.A4.IP.100 | 13d |  | HH MAHRTUNEL [285.7 h] |
|  | 5 | **DIQUE DE TIERRA COMPACTADA A4-BS-D-01 - BRAZO SECUNDARIO** |  | 2023-02-12 | 2023-04-07 |  |  |  |  |
| D.A4.DS.010 |  | EXCAVACIÓN EN TERRENO NATURAL CON EQUIPO | 9d | 2023-02-12 | 2023-02-20 | D.A4.I1.010 | 0d |  |  |
| D.A4.DS.020 |  | TRANSPORTE DE MATERIAL EXCEDENTE | 9d | 2023-02-12 | 2023-02-20 | D.A4.DS.010 SS | 67d |  |  |
| D.A4.DS.030 |  | PREPARACIÓN DE FUNDACIÓN DE CUERPO DE DIQUE | 18d | 2023-02-17 | 2023-03-06 | D.A4.DS.010 SS+5d | 21d | 0d |  |
| D.A4.DS.035 |  | CONFORMACION DE CUERPO DE DIQUE | 18d | 2023-02-20 | 2023-03-09 | D.A4.DS.030 SS+3d | 21d | 0d |  |
| D.A4.DS.050 |  | EXCAVACIÓN EN UÑA CON EQUIPO | 18d | 2023-02-25 | 2023-03-14 | D.A4.DS.035 SS+5d | 21d | 0d |  |
| D.A4.DS.060 |  | PERFILADO Y COMPACTACIÓN EN ZONA DE CORTE | 18d | 2023-02-27 | 2023-03-16 | D.A4.DS.050 SS+2d | 21d | 0d | HH MAHRTUNEL [40.1 h] |
| D.A4.DS.070 |  | COLOCACIÓN DE GEOTEXTIL NO TEJIDO 400 gr/m2 | 18d | 2023-03-01 | 2023-03-18 | D.A4.DS.060 SS+2d | 21d | 0d | HH MAHRTUNEL [67 h] |
| D.A4.DS.080 |  | TRANSPORTE DE ROCA | 30d | 2023-03-01 | 2023-03-30 | D.A4.DS.070 SS | 21d | 0d | ROCA [205] |
| D.A4.DS.090 |  | COLOCACIÓN Y ACOMODO DE ROCA EN UÑA DEL DIQUE | 21d | 2023-03-02 | 2023-03-22 | D.A4.DS.080 SS+1d | 21d | 0d |  |
| D.A4.DS.100 |  | COLOCACIÓN Y ACOMODO DE ROCA EN TALUD DEL DIQUE | 24d | 2023-03-10 | 2023-04-02 | D.A4.DS.090 SS+8d | 21d | 0d |  |
| D.A4.DS.110 |  | CONFORMACIÓN DE MATERIAL GRANULAR EN CORONA DE DIQUE (e=0.30 m) | 5d | 2023-04-03 | 2023-04-07 | D.A4.DS.100 | 21d |  | HH MAHRTUNEL [285.7 h] |

| ID | WBS | Activity | Duration | Start | Finish | Predecessors | Total float | Free float | Resources |
| --- | --- | --- | --- | --- | --- | --- | --- | --- | --- |
|  | 4 | **DIQUE DE TIERRA COMPACTADA A4-BS-I-01 - BRAZO SECUNDARIO** |  | 2023-02-21 | 2023-04-24 |  |  |  |  |
| D.A4.DI.010 |  | EXCAVACIÓN EN TERRENO NATURAL CON EQUIPO | 4d | 2023-02-21 | 2023-02-24 | D.A4.DS.010 | 0d |  |  |
| D.A4.DI.020 |  | TRANSPORTE DE MATERIAL EXCEDENTE | 4d | 2023-02-21 | 2023-02-24 | D.A4.DI.010 SS | 63d |  |  |
| D.A4.DI.030 |  | PREPARACIÓN DE FUNDACIÓN DE CUERPO DE DIQUE | 12d | 2023-02-25 | 2023-03-08 | D.A4.DI.010 | 0d |  |  |
| D.A4.DI.040 |  | CONFORMACION DE CUERPO DE DIQUE | 12d | 2023-02-28 | 2023-03-11 | D.A4.DI.030 SS+3d | 0d |  |  |
| D.A4.DI.050 |  | EXCAVACIÓN EN UÑA CON EQUIPO | 12d | 2023-03-04 | 2023-03-15 | D.A4.DI.040 SS+4d | 0d |  |  |
| D.A4.DI.060 |  | PERFILADO Y COMPACTACIÓN EN ZONA DE CORTE | 12d | 2023-03-06 | 2023-03-17 | D.A4.DI.050 SS+2d | 0d |  | HH MAHRTUNEL [40.1 h] |
| D.A4.DI.070 |  | COLOCACIÓN DE GEOTEXTIL NO TEJIDO 400 gr/m2 | 12d | 2023-03-08 | 2023-03-19 | D.A4.DI.060 SS+2d | 0d |  | HH MAHRTUNEL [67 h] |
| D.A4.DI.080 |  | TRANSPORTE DE ROCA | 43d | 2023-03-08 | 2023-04-19 | D.A4.DI.070 SS | 0d |  | ROCA [205] |
| D.A4.DI.090 |  | COLOCACIÓN Y ACOMODO DE ROCA EN UÑA DEL DIQUE | 28d | 2023-03-09 | 2023-04-05 | D.A4.DI.080 SS+1d | 0d |  |  |
| D.A4.DI.100 |  | COLOCACIÓN Y ACOMODO DE ROCA EN TALUD DEL DIQUE | 34d | 2023-03-19 | 2023-04-21 | D.A4.DI.090 SS+10d | 0d |  |  |
| D.A4.DI.110 |  | CONFORMACIÓN DE MATERIAL GRANULAR EN CORONA DE DIQUE (e=0.30 m) | 3d | 2023-04-22 | 2023-04-24 | D.A4.DI.100 | 0d |  | HH MAHRTUNEL [285.7 h] |
|  | 2 | **RAMPAS** |  | 2023-03-16 | 2023-03-21 |  |  |  |  |
| R.010 |  | EXCAVACIÓN EN TERRENO NATURAL CON EQUIPO | 2d | 2023-03-16 | 2023-03-17 | D.A4.DI.050 | 37d | 0d | HH MAHRTUNEL [56 h] |
| R.020 |  | CONFORMACIÓN DE CUERPO DE RAMPA CON MATERIAL PROPIO | 3d | 2023-03-18 | 2023-03-20 | R.010 | 38d | 0d | HH MAHRTUNEL [40.1 h] |
| R.030 |  | CONFORMACIÓN DE MATERIAL GRANULAR EN CORONA DE DIQUE | 1d | 2023-03-21 | 2023-03-21 | R.020 | 38d |  | HH MAHRTUNEL [23 h] |
|  | 3 | **MUROS DE CONCRETO ARMADO SOBRE CANAL HUACA NEPEÑA** |  | 2023-01-20 | 2023-02-15 |  |  |  |  |
| MC.010 |  | EXCAVACIÓN ESTRUCTURAL PARA OBRAS DE ARTE | 1d | 2023-01-20 | 2023-01-20 | RE.250 FS+7d | 70d | 0d |  |
| MC.030 |  | CONCRETO F'C=100 Kg/cm2 | 1d | 2023-01-21 | 2023-01-21 | MC.010 | 72d | 0d |  |
| MC.040 |  | ESTRUCTURA DE MURO CONCRETO F'C=280 Kg/cm2 | 20d | 2023-01-22 | 2023-02-10 | MC.030 | 72d | 0d |  |
| MC.050 |  | RELLENO ESTRUCTURAL PARA OBRAS DE ARTE CON MATERIAL PROPIO | 2d | 2023-02-14 | 2023-02-15 | MC.040 FS+3d | 72d |  |  |
|  | 4 | **RETORNO EVACUADOR TOMA 4A** |  | 2023-01-21 | 2023-02-17 |  |  |  |  |
| D.05.120 |  | EXCAVACIÓN ESTRUCTURAL PARA OBRAS DE ARTE | 2d | 2023-01-21 | 2023-01-22 | MC.010 | 70d | 0d | HH MAHRTUNEL [23 h] |
| D.05.130 |  | CAMA DE ARENA | 5d | 2023-01-23 | 2023-01-27 | D.05.120 | 70d | 0d | HH MAHRTUNEL [40.1 h] |
| D.05.140 |  | INSTALACIÓN DE TUBERÍA HDPE DN600 mm | 5d | 2023-01-24 | 2023-01-28 | D.05.130 SS+1d | 70d | 0d | HH MAHRTUNEL [67 h] |
| D.05.150 |  | CONCRETO F'C=100 Kg/cm2 | 2d | 2023-01-29 | 2023-01-30 | D.05.140 | 70d | 0d | HH MAHRTUNEL [285.7 h] |
| D.05.160 |  | CONCRETO F'C=280 Kg/cm2 | 15d | 2023-01-31 | 2023-02-14 | D.05.150 | 70d | 0d |  |
| D.05.180 |  | RELLENO ESTRUCTURAL PARA OBRAS DE ARTE CON MATERIAL PROPIO | 4d | 2023-02-14 | 2023-02-17 | D.05.170 FF | 70d |  |  |
| D.05.170 |  | COMPUERTA DE CHARNELA DN600 mm | 3d | 2023-02-15 | 2023-02-17 | D.05.160 | 70d | 0d |  |

| ID | WBS | Activity | Duration | Start | Finish | Predecessors | Total float | Free float | Resources |
| --- | --- | --- | --- | --- | --- | --- | --- | --- | --- |
|  | 70.2 | **SUBPROYECTO A4 PAMPA DEL TORO** |  | 2022-12-31 | 2023-02-20 |  |  |  |  |
|  | 02 | **CARRETERAS, CAMINOS, PAVIMENTOS** |  | 2022-12-31 | 2023-01-23 |  |  |  |  |
|  | 01 | **MEJORAMIENTO DE VIAS EXISTENTES** |  | 2022-12-31 | 2023-01-23 |  |  |  |  |
|  | 01 | **MOVIMIENTO DE TIERRAS** |  | 2022-12-31 | 2023-01-15 |  |  |  |  |
| MV.010 |  | ROCE Y LIMPIEZA DE MALEZA | 5d | 2022-12-31 | 2023-01-04 | MV.200 FS+3d | 71d | 4d |  |
| MV.020 |  | MEJORAMIENTO DE VIAS EXISTENTES - VIA DE ACCESO A DME 13 | 3d | 2023-01-07 | 2023-01-09 | MV.010 SS+3d, MV.210 | 67d | 0d |  |
| MV.030 |  | MEJORAMIENTO DE VIAS EXISTENTES - VIA DE ACCESO A DIQUE MI | 3d | 2023-01-10 | 2023-01-12 | MV.020 | 67d | 0d |  |
| MV.040 |  | MEJORAMIENTO DE VIAS EXISTENTES - VIA DE ACCESO A DIQUE MD | 3d | 2023-01-13 | 2023-01-15 | MV.030 | 67d | 0d |  |
|  | 02 | **REPOSICIÓN DE ESTRUCTURAS** |  | 2023-01-10 | 2023-01-23 |  |  |  |  |
| RE.010 |  | DEMOLICIÓN DE ESTRUCTURAS EXISTENTES | 2d | 2023-01-10 | 2023-01-11 | MV.020 | 95d | 0d |  |
| RE.020 |  | REPOSICIÓN DE PASE DE AGUA TUBERÍA HDPE CORRUGADA Ø=24" | 4d | 2023-01-12 | 2023-01-15 | RE.010 | 95d | 0d |  |
| RE.040 |  | REPOSICIÓN DE PASE DE AGUA TUBERÍA HDPE CORRUGADA Ø=36" | 4d | 2023-01-12 | 2023-01-15 | RE.020 SS | 95d | 0d |  |
| RE.060 |  | MONTAJE DE LOSA CONCRETO 1.6mx1.0mx0.20m EN PASE DE AGUA | 2d | 2023-01-13 | 2023-01-14 | MV.030 | 72d | 1d |  |
| RE.030 |  | ESTRUCTURA DE CONCRETO 175 Kg/cm2 DE CABEZAL ENTRADA Y SALIDA DE TUB. HDPE CORRUGADA Ø=24" | 8d | 2023-01-16 | 2023-01-23 | RE.020 | 95d | 0d |  |
| RE.050 |  | ESTRUCTURA DE CONCRETO 175 Kg/cm2 DE CABEZAL ENTRADA Y SALIDA DE TUB. HDPE CORRUGADA Ø=36" | 8d | 2023-01-16 | 2023-01-23 | RE.040, RE.030 SS | 95d |  |  |
|  | 00 | **GENERAL** |  | 2023-01-10 | 2023-02-20 |  |  |  |  |
|  | 2 | **PROGRAMA DE CIERRE DE OBRA** |  | 2023-01-10 | 2023-02-20 |  |  |  |  |
| PCO.020 |  | RETIRO Y ALMACENAMIENTO DE TOPSOIL DEL DME | 4d | 2023-01-10 | 2023-01-13 | MV.020 | 89d | 5d |  |
| PCO.030 |  | ACONDICIONAMIENTO DE MATERIAL EN BOTADERO | 16d | 2023-01-19 | 2023-02-03 | D.03.010 SS, PCO.020 | 84d |  |  |
| PCO.040 |  | COLOCACIÓN DE CAPA SUPERFICIAL DEL DME | 4d | 2023-02-15 | 2023-02-18 | D.03.015, D.05.045, D.05.040, RC.020 | 69d |  |  |
| PCO.050 |  | RESTAURACIÓN DE ÁREAS DE INSTALACIONES PROVISIONALES | 3d | 2023-02-18 | 2023-02-20 | RC.040, D.05.110, PLR-01-050, I-03.090 | 67d |  |  |
|  | 14 | **REFUERZO DE RIBERA DEL RIO** |  | 2023-01-16 | 2023-02-17 |  |  |  |  |
|  | 5 | **PROTECCIÓN DEL CAUCE CON ENROCADO (A4-PT-PLR-01)-AGUA ABAJO** |  | 2023-01-16 | 2023-01-23 |  |  |  |  |
| PLR-01-010 |  | DESBROCE Y LIMPIEZA EN ZONA NO BOSCOSA | 1d | 2023-01-16 | 2023-01-16 | MV.040, RE.060 | 71d | 0d |  |
| PLR-01-020 |  | EXCAVACIÓN EN MATERIAL SUELTO CON EQUIPO | 2d | 2023-01-17 | 2023-01-18 | PLR-01-010 | 71d | 0d |  |
| PLR-01-030 |  | PERFILADO Y COMPACTACIÓN CON EQUIPO DE FONDO DE EXCAVACIÓN | 2d | 2023-01-18 | 2023-01-19 | PLR-01-020 FF+1d | 74d | 0d |  |
| PLR-01-040 |  | TRANSPORTE DE ROCA | 5d | 2023-01-18 | 2023-01-22 | PLR-01-030 SS | 74d | 0d | ROCA [541] |
| PLR-01-050 |  | COLOCACIÓN DE ROCA EN CAUCE | 5d | 2023-01-19 | 2023-01-23 | PLR-01-040 SS+1d | 74d | 1d |  |

| ID | WBS | Activity | Duration | Start | Finish | Predecessors | Total float | Free float | Resources |
| --- | --- | --- | --- | --- | --- | --- | --- | --- | --- |
|  | 10 | **PROTECCION DE TALUDES (A4-PT-D-03)** |  | 2023-01-19 | 2023-01-28 |  |  |  |  |
| D.03.010 |  | DESBROCE Y LIMPIEZA EN ZONA NO BOSCOSA | 1d | 2023-01-19 | 2023-01-19 | PLR-01-020 | 71d | 0d |  |
| D.03.015 |  | TRANSPORTE DE MATERIAL EXCEDENTE | 1d | 2023-01-19 | 2023-01-19 | D.03.010 SS | 95d | 26d |  |
| D.03.020 |  | RELLENO ESTRUCTURAL CON MATERIAL PROPIO EN TALUD EXISTENTE | 2d | 2023-01-20 | 2023-01-21 | D.03.010 | 71d | 0d |  |
| D.03.030 |  | EXCAVACIÓN EN TERRENO NATURAL CON EQUIPO | 1d | 2023-01-22 | 2023-01-22 | D.03.020 | 71d | 0d |  |
| D.03.040 |  | PERFILADO Y COMPACTACIÓN EN ZONA DE CORTE | 1d | 2023-01-23 | 2023-01-23 | D.03.030 | 71d | 0d |  |
| D.03.060 |  | COLOCACIÓN DE GEOTEXTIL NO TEJIDO 400 gr/m2 | 1d | 2023-01-24 | 2023-01-24 | D.03.040 | 73d | 0d |  |
| D.03.070 |  | TRANSPORTE DE ROCA | 4d | 2023-01-24 | 2023-01-27 | D.03.060 SS | 73d | 0d | ROCA [108] |
| D.03.080 |  | COLOCACIÓN Y ACOMODO DE ROCA EN UÑA DEL DIQUE | 2d | 2023-01-25 | 2023-01-26 | D.03.070 SS+1d, PLR-01-050 | 73d | 0d |  |
| D.03.090 |  | COLOCACIÓN Y ACOMODO DE ROCA EN TALUD DEL DIQUE | 2d | 2023-01-27 | 2023-01-28 | D.03.080 | 73d | 2d |  |
|  | 1 | **PROTECCION DE TALUDES (A4-PT-I-02)** |  | 2023-01-24 | 2023-02-05 |  |  |  |  |
| I-02.010 |  | DESBROCE Y LIMPIEZA EN ZONA NO BOSCOSA | 1d | 2023-01-24 | 2023-01-24 | D.03.040 | 71d | 0d | HH MAHRTUNEL [23 h] |
| I-02.020 |  | TRANSPORTE DE MATERIAL EXCEDENTE | 1d | 2023-01-24 | 2023-01-24 | I-02.010 SS | 94d |  | HH MAHRTUNEL [227.1 h] |
| I-02.030 |  | RELLENO ESTRUCTURAL CON MATERIAL PROPIO EN TALUD EXISTENTE | 2d | 2023-01-25 | 2023-01-26 | I-02.010 | 71d | 0d |  |
| I-02.040 |  | EXCAVACIÓN EN TERRENO NATURAL CON EQUIPO | 2d | 2023-01-27 | 2023-01-28 | I-02.030 | 71d | 0d | HH MAHRTUNEL [56 h] |
| I-02.050 |  | PERFILADO Y COMPACTACIÓN EN ZONA DE CORTE | 2d | 2023-01-28 | 2023-01-29 | I-02.040 FF+1d | 71d | 0d | HH MAHRTUNEL [40.1 h] |
| I-02.060 |  | COLOCACIÓN DE GEOTEXTIL NO TEJIDO 400 gr/m2 | 2d | 2023-01-30 | 2023-01-31 | I-02.050 | 71d | 0d | HH MAHRTUNEL [67 h] |
| I-02.070 |  | TRANSPORTE DE ROCA | 6d | 2023-01-30 | 2023-02-04 | I-02.060 SS | 71d | 0d | ROCA [108] |
| I-02.080 |  | COLOCACIÓN Y ACOMODO DE ROCA EN UÑA DEL DIQUE | 2d | 2023-01-31 | 2023-02-01 | I-02.070 SS+1d, D.03.090 | 71d | 0d |  |
| I-02.090 |  | COLOCACIÓN Y ACOMODO DE ROCA EN TALUD DEL DIQUE | 4d | 2023-02-02 | 2023-02-05 | I-02.080 | 71d | 0d |  |
|  | 2 | **PROTECCION DE TALUDES (A4-PT-I-03)** |  | 2023-01-30 | 2023-02-13 |  |  |  |  |
| I-03.010 |  | DESBROCE Y LIMPIEZA EN ZONA NO BOSCOSA | 1d | 2023-01-30 | 2023-01-30 | D.04.050, I-02.050 | 72d | 0d | HH MAHRTUNEL [23 h] |
| I-03.020 |  | RELLENO ESTRUCTURAL CON MATERIAL PROPIO EN TALUD EXISTENTE | 2d | 2023-01-31 | 2023-02-01 | I-03.010 | 72d | 0d |  |
| I-03.030 |  | EXCAVACIÓN EN TERRENO NATURAL CON EQUIPO | 1d | 2023-02-02 | 2023-02-02 | I-03.020 | 72d | 0d | HH MAHRTUNEL [56 h] |
| I-03.040 |  | PERFILADO Y COMPACTACIÓN EN ZONA DE CORTE | 1d | 2023-02-03 | 2023-02-03 | I-03.030 | 72d | 0d | HH MAHRTUNEL [40.1 h] |
| I-03.045 |  | TRANSPORTE DE MATERIAL EXCEDENTE | 1d | 2023-02-03 | 2023-02-03 | I-03.040 SS | 84d |  | HH MAHRTUNEL [227.1 h] |
| I-03.060 |  | COLOCACIÓN DE GEOTEXTIL NO TEJIDO 400 gr/m2 | 2d | 2023-02-04 | 2023-02-05 | I-03.040 | 72d | 0d | HH MAHRTUNEL [67 h] |
| I-03.070 |  | TRANSPORTE DE ROCA | 8d | 2023-02-04 | 2023-02-11 | I-03.060 SS | 72d | 1d | ROCA [529] |
| I-03.080 |  | COLOCACIÓN Y ACOMODO DE ROCA EN UÑA DEL DIQUE | 4d | 2023-02-06 | 2023-02-09 | I-03.070 SS+1d, I-02.090 | 71d | 0d |  |
| I-03.090 |  | COLOCACIÓN Y ACOMODO DE ROCA EN TALUD DEL DIQUE | 4d | 2023-02-10 | 2023-02-13 | I-03.080 | 71d | 4d |  |

| ID | WBS | Activity | Duration | Start | Finish | Predecessors | Total float | Free float | Resources |
| --- | --- | --- | --- | --- | --- | --- | --- | --- | --- |
|  | 3 | **PROTECCIÓN DEL CAUCE CON ENROCADO (A4-PT-PLR-01)-AGUAS ARRIBA** |  | 2023-01-16 | 2023-01-24 |  |  |  |  |
| PLR-01-060 |  | DESBROCE Y LIMPIEZA EN ZONA NO BOSCOSA | 1d | 2023-01-16 | 2023-01-16 | MV.040 | 67d | 0d |  |
| PLR-01-070 |  | EXCAVACIÓN EN MATERIAL SUELTO CON EQUIPO | 2d | 2023-01-17 | 2023-01-18 | PLR-01-060 | 67d | 0d |  |
| PLR-01-080 |  | PERFILADO Y COMPACTACIÓN CON EQUIPO DE FONDO DE EXCAVACIÓN | 1d | 2023-01-19 | 2023-01-19 | PLR-01-070 FF+1d | 67d | 0d |  |
| PLR-01-090 |  | TRANSPORTE DE ROCA | 5d | 2023-01-19 | 2023-01-23 | PLR-01-080 SS | 71d | 0d | ROCA [541] |
| PLR-01-100 |  | COLOCACIÓN DE ROCA EN CAUCE | 5d | 2023-01-20 | 2023-01-24 | PLR-01-090 SS+1d | 71d | 2d |  |
|  | 9 | **DIQUE DE TIERRA COMPACTADA (A4-PT- D-04)** |  | 2023-01-20 | 2023-01-31 |  |  |  |  |
| D.04.010 |  | DESBROCE Y LIMPIEZA EN ZONA NO BOSCOSA | 2d | 2023-01-20 | 2023-01-21 | PLR-01-080 | 67d | 0d |  |
| D.04.030 |  | CONFORMACION DE CUERPO DE DIQUE | 2d | 2023-01-22 | 2023-01-23 | D.04.010 | 67d | 0d |  |
| D.04.040 |  | EXCAVACIÓN EN TERRENO NATURAL CON EQUIPO | 2d | 2023-01-23 | 2023-01-24 | D.04.030 FF+1d | 67d | 0d |  |
| D.04.045 |  | TRANSPORTE DE MATERIAL EXCEDENTE | 2d | 2023-01-23 | 2023-01-24 | D.04.040 SS | 94d |  |  |
| D.04.050 |  | PERFILADO Y COMPACTACIÓN EN ZONA DE CORTE | 2d | 2023-01-24 | 2023-01-25 | D.04.040 FF+1d | 69d | 0d | HH MAHRTUNEL [40.1 h] |
| D.04.060 |  | COLOCACIÓN DE GEOTEXTIL NO TEJIDO 400 gr/m2 | 2d | 2023-01-26 | 2023-01-27 | D.04.050 | 69d | 0d | HH MAHRTUNEL [67 h] |
| D.04.070 |  | TRANSPORTE DE ROCA | 4d | 2023-01-26 | 2023-01-29 | D.04.060 SS | 69d | 0d | ROCA [205] |
| D.04.080 |  | COLOCACIÓN Y ACOMODO DE ROCA EN UÑA DEL DIQUE | 2d | 2023-01-27 | 2023-01-28 | D.04.070 SS+1d, PLR-01-100 | 69d | 0d |  |
| D.04.090 |  | COLOCACIÓN Y ACOMODO DE ROCA EN TALUD DEL DIQUE | 2d | 2023-01-29 | 2023-01-30 | D.04.080 | 69d | 0d |  |
| D.04.100 |  | CONFORMACIÓN DE MATERIAL GRANULAR EN CORONA DE DIQUE (e=0.30 m) | 1d | 2023-01-31 | 2023-01-31 | D.04.090 | 87d |  | HH MAHRTUNEL [285.7 h] |
|  | 4 | **DIQUE DE TIERRA COMPACTADA (A4-PT- D-05)** |  | 2023-01-27 | 2023-02-13 |  |  |  |  |
| D.05.010 |  | DESBROCE Y LIMPIEZA EN ZONA NO BOSCOSA | 2d | 2023-01-27 | 2023-01-28 | D.04.040 FS+2d | 67d | 0d | HH MAHRTUNEL [23 h] |
| D.05.030 |  | CONFORMACION DE CUERPO DE DIQUE | 3d | 2023-01-29 | 2023-01-31 | D.05.010 | 67d | 0d |  |
| D.05.040 |  | EXCAVACIÓN EN TERRENO NATURAL CON EQUIPO | 2d | 2023-01-31 | 2023-02-01 | D.05.030 FF+1d | 67d | 0d |  |
| D.05.045 |  | TRANSPORTE DE MATERIAL EXCEDENTE | 2d | 2023-01-31 | 2023-02-01 | D.05.040 SS | 82d | 13d | HH MAHRTUNEL [227.1 h] |
| D.05.050 |  | PERFILADO Y COMPACTACIÓN EN ZONA DE CORTE | 3d | 2023-01-31 | 2023-02-02 | D.05.040 FF+1d | 67d | 0d | HH MAHRTUNEL [40.1 h] |
| D.05.070 |  | COLOCACIÓN DE GEOTEXTIL NO TEJIDO 400 gr/m2 | 3d | 2023-02-01 | 2023-02-03 | D.05.050 SS+1d | 67d | 0d | HH MAHRTUNEL [67 h] |
| D.05.080 |  | TRANSPORTE DE ROCA | 8d | 2023-02-01 | 2023-02-08 | D.05.070 SS | 67d | 0d | ROCA [677] |
| D.05.090 |  | COLOCACIÓN Y ACOMODO DE ROCA EN UÑA DEL DIQUE | 6d | 2023-02-02 | 2023-02-07 | D.05.080 SS+1d, D.04.090 | 67d | 0d |  |
| D.05.100 |  | COLOCACIÓN Y ACOMODO DE ROCA EN TALUD DEL DIQUE | 4d | 2023-02-08 | 2023-02-11 | D.05.090 | 67d | 0d |  |
| D.05.110 |  | CONFORMACIÓN DE MATERIAL GRANULAR EN CORONA DE DIQUE (e=0.30 m) | 2d | 2023-02-12 | 2023-02-13 | D.05.100 | 71d | 4d | HH MAHRTUNEL [285.7 h] |

| ID | WBS | Activity | Duration | Start | Finish | Predecessors | Total float | Free float | Resources |
| --- | --- | --- | --- | --- | --- | --- | --- | --- | --- |
|  | 7 | **REPOSICIÓN DE CAMINO DE ACCESO (A4-RC-1)** |  | 2023-02-12 | 2023-02-17 |  |  |  |  |
| RC.010 |  | DESBROCE Y LIMPIEZA EN ZONA NO BOSCOSA | 1d | 2023-02-12 | 2023-02-12 | D.05.100 | 67d | 0d | HH MAHRTUNEL [24.8 h] |
| RC.020 |  | EXCAVACIÓN EN MATERIAL SUELTO CON EQUIPO | 2d | 2023-02-13 | 2023-02-14 | RC.010 | 67d | 0d | HH MAHRTUNEL [30.2 h] |
| RC.030 |  | PERFILADO Y COMPACTACIÓN EN ZONA DE CORTE | 2d | 2023-02-15 | 2023-02-16 | RC.020 | 67d | 0d | HH MAHRTUNEL [46.2 h] |
| RC.040 |  | MATERIAL AFIRMADO e=25 cm | 1d | 2023-02-17 | 2023-02-17 | RC.030 | 67d | 0d | HH MAHRTUNEL [177.2 h] |

## Issues

| Issue | Status | Raised | Activity | Notes |
| --- | --- | --- | --- | --- |
| Free Float (days) is 0 on Activity: HP.020 | IS_Open | 2020-08-11 | HP.010 | ? |
| Free Float (days) is 0 on Activity: HP.030 | IS_Open | 2020-08-11 | HP.040 | ? |
| Free Float (days) is 0 on Activity: TP.010 | IS_Open | 2020-08-11 | OP.010 | ? |
| (New Issue) | IS_Open | 2020-06-01 |  | ? |
